# High Level Plan for SAPBiz 10-22-08 v4

Schedule from MS Project, 2008-09-15 to 2008-12-23.
MIT

## Calendars

- Standard: Mon-Fri 08:00-12:00, 13:00-17:00; Sat-Sun off. Exceptions (off unless hours are given): 2008-09-20 to 2008-09-21, 2008-09-27 to 2008-09-28, 2008-10-04 to 2008-10-05, 2008-10-11 to 2008-10-12, 2008-10-18 to 2008-10-19, 2008-10-25 to 2008-10-26, 2008-11-01 to 2008-11-02, 2008-11-08 to 2008-11-09, 2008-11-11, 2008-11-15 to 2008-11-16, 2008-11-22 to 2008-11-23, 2008-11-27 to 2008-11-30, 2008-12-06 to 2008-12-07, 2008-12-13 to 2008-12-14 08:00-12:00, 13:00-17:00, 2008-12-20 to 2008-12-21.

## Resources

| Resource |
| --- |
| ABAP |
| BO |
| CAO |
| BASIS |
| BA |
| DEV |
| DWH |
| HR-P |
| ALL |
| 20 |
| BUS |
| 8 |
| 7 |
| REP |
| R3 |
| QA |
| FIN |
| LOG |
| EHS |
| HRP |
| IDD |
| ISS |
| R# |
| FQ |
| FI |

## Schedule

| ID | WBS | Task | Type | Duration | Start | Finish | Predecessors | Total slack | Free slack | Constraint | Resources | Work |
| --- | --- | --- | --- | --- | --- | --- | --- | --- | --- | --- | --- | --- |
| 1 | 1 | **2008 Support Pack Implementation Project** |  | 70d | 2008-09-15 08:00 | 2008-12-23 08:00 |  | 0d |  |  |  | 2510h |
| 2 | 1.1 | **Project Prep & Planning** |  | 36.5d | 2008-09-15 08:00 | 2008-11-04 12:00 |  | 6.75d |  |  |  | 1568h |
| 3 | 1.1.1 | Determine support packages availability date (10/20/08 per SAP Service Marketplace) |  | 0.5d | 2008-09-15 08:00 | 2008-09-15 12:00 |  | 69.5d |  | start no earlier than 2008-09-15 08:00 |  |  |
| 4 | 1.1.2 | Determine desired support package levels (see wiki for detailed list) |  | 0.5d | 2008-09-22 08:00 | 2008-09-22 12:00 |  | 64.5d |  |  |  |  |
| 5 | 1.1.3 | Identify clients fo Staging, and TST (DEV not refreshed) |  | 0.5d | 2008-09-22 08:00 | 2008-09-22 12:00 |  | 64.5d |  |  |  |  |
| 6 | 1.1.4 | Determine production snapshot dates for STG, TST (9/22, 10/20, respectively) |  | 0.5d | 2008-09-22 08:00 | 2008-09-22 12:00 |  | 64.5d |  |  |  |  |
| 7 | 1.1.5 | Determine dates for STG, TST refreshes |  | 0.5d | 2008-09-22 08:00 | 2008-09-22 12:00 |  | 64.5d |  |  |  |  |
| 8 | 1.1.6 | Determine dates for production freeze (2008: 10/31/08 - 1/8/09) |  | 0.5d | 2008-09-22 08:00 | 2008-09-22 12:00 |  | 64.5d |  |  |  |  |
| 9 | 1.1.7 | Update business owner list with new / changed owners |  | 0.5d | 2008-09-22 08:00 | 2008-09-22 12:00 |  | 14.25d |  |  | FIN; LOG; EHS; HRP | 16h |
| 10 | 1.1.8 | PS1 Snapshot at end of day for SF3 refresh | milestone | 0d | 2008-09-22 08:00 | 2008-09-22 08:00 |  | 65d |  | start no earlier than 2008-09-22 08:00 |  |  |
| 11 | 1.1.9 | Transaction list available | milestone | 0d | 2008-09-24 08:00 | 2008-09-24 08:00 |  | 63d |  | start no earlier than 2008-09-24 08:00 | R3 |  |
| 12 | 1.1.10 | SF3 Unavailable at end of day | milestone | 0d | 2008-10-10 08:00 | 2008-10-10 08:00 |  | 51d | 6d | start no earlier than 2008-10-10 08:00 |  |  |
| 13 | 1.1.11 | PS1 snapshot at end of day | milestone | 0d | 2008-10-20 08:00 | 2008-10-20 08:00 |  | 45d |  | start no earlier than 2008-10-20 08:00 | R3 |  |
| 14 | 1.1.12 | Save data warehouse extracts | milestone | 0d | 2008-10-20 08:00 | 2008-10-20 08:00 | 12 | 45d |  | start no earlier than 2008-10-20 08:00 | DWH |  |
| 15 | 1.1.13 | Support packs available from SAP | milestone | 0d | 2008-10-20 08:00 | 2008-10-20 08:00 |  | 10d | 0d | start no earlier than 2008-10-20 08:00 |  |  |
| 16 | 1.1.14 | PS1 Import 1 | milestone | 0d | 2008-10-23 08:00 | 2008-10-23 08:00 |  | 42d |  | start no earlier than 2008-10-23 08:00 |  |  |
| 17 | 1.1.15 | PS1 Import - regular import cycle | milestone | 0d | 2008-10-23 08:00 | 2008-10-23 08:00 |  | 42d |  | start no earlier than 2008-10-23 08:00 |  |  |
| 18 | 1.1.16 | Production Imports (last regular import cycle) | milestone | 0d | 2008-10-30 08:00 | 2008-10-30 08:00 |  | 37d | 1d | start no earlier than 2008-10-30 08:00 |  |  |
| 19 | 1.1.17 | Development slowdown starts | milestone | 0d | 2008-10-31 08:00 | 2008-10-31 08:00 | 18 | 36d |  | start no earlier than 2008-10-31 08:00 |  |  |
| 20 | 1.1.18 | **Test Planning** |  | 31.5d | 2008-09-22 08:00 | 2008-11-04 12:00 |  | 1.75d |  |  |  | 1552h |
| 21 | 1.1.18.1 | **Update test script catalogs** |  | 13d | 2008-09-22 08:00 | 2008-10-08 17:00 |  | 1.75d |  |  |  | 416h |
| 22 | 1.1.18.1.1 | Review transaction / report log for new items |  | 5d | 2008-09-22 08:00 | 2008-09-26 17:00 |  | 1.75d | 0d |  | FIN; LOG; EHS; HRP | 160h |
| 23 | 1.1.18.1.2 | Update test script catalog with new transactions / reports |  | 1d | 2008-09-29 08:00 | 2008-09-29 17:00 | 22 | 1.75d | 0d |  | FIN; LOG; EHS; HRP | 32h |
| 24 | 1.1.18.1.3 | Review test script catalog for missing / old test scripts |  | 2d | 2008-09-30 08:00 | 2008-10-01 17:00 | 23 | 1.75d | 0d |  | FIN; LOG; EHS; HRP | 64h |
| 25 | 1.1.18.1.4 | Create new / update old test scripts |  | 5d | 2008-10-02 08:00 | 2008-10-08 17:00 | 24 | 1.75d | 0d |  | FIN; LOG; EHS; HRP | 160h |
| 26 | 1.1.18.1.5 | Financial Team confirms completeness of test script catalog | milestone | 0d | 2008-10-08 17:00 | 2008-10-08 17:00 | 25 | 1.75d |  |  | FIN |  |
| 27 | 1.1.18.1.6 | Logistics Team confirms completeness of test script catalog | milestone | 0d | 2008-10-08 17:00 | 2008-10-08 17:00 | 25 | 52d |  | start no earlier than 2008-09-20 08:00 | LOG |  |
| 28 | 1.1.18.1.7 | EHS Team confirms completeness of test script catalog | milestone | 0d | 2008-10-08 17:00 | 2008-10-08 17:00 | 25 | 52d |  | start no earlier than 2008-09-20 08:00 | EHS |  |
| 29 | 1.1.18.1.8 | HR-Payroll Team confirms completeness of test script catalog | milestone | 0d | 2008-10-08 17:00 | 2008-10-08 17:00 | 25 | 33.5d | 0d | start no earlier than 2008-09-20 08:00 | HRP |  |

| ID | WBS | Task | Type | Duration | Start | Finish | Predecessors | Total slack | Free slack | Constraint | Resources | Work |
| --- | --- | --- | --- | --- | --- | --- | --- | --- | --- | --- | --- | --- |
| 30 | 1.1.18.2 | **Unit Test Planning** |  | 1.5d | 2008-10-09 08:00 | 2008-10-10 12:00 |  | 33.5d |  |  |  | 48h |
| 31 | 1.1.18.2.1 | Determine transactions / reports to be tested |  | 1d | 2008-10-09 08:00 | 2008-10-09 17:00 | 29 | 33.5d | 0d |  | FIN; LOG; EHS; HRP | 32h |
| 32 | 1.1.18.2.2 | Update test script catalog |  | 0.5d | 2008-10-10 08:00 | 2008-10-10 12:00 | 31 | 33.5d | 0d |  | FIN; LOG; EHS; HRP | 16h |
| 33 | 1.1.18.3 | **Systems Integration Test Planning** |  | 17d | 2008-10-10 13:00 | 2008-11-04 12:00 |  | 33.5d |  |  |  | 448h |
| 34 | 1.1.18.3.1 | Define business scenarios |  | 2d | 2008-10-10 13:00 | 2008-10-14 12:00 | 32 | 33.5d | 0d |  | FIN; LOG; EHS; HRP | 64h |
| 35 | 1.1.18.3.2 | Document business scenarios |  | 10d | 2008-10-14 13:00 | 2008-10-28 12:00 | 34 | 33.5d | 0d |  | FIN; LOG; EHS; HRP | 320h |
| 36 | 1.1.18.3.3 | QA review of business scenarios |  | 3d | 2008-10-28 13:00 | 2008-10-31 12:00 | 35 | 33.5d | 0d |  | QA | 24h |
| 37 | 1.1.18.3.4 | Update business scenarios as required |  | 1d | 2008-10-31 13:00 | 2008-11-03 12:00 | 36 | 33.5d | 0d |  | FIN; LOG; EHS; HRP | 32h |
| 38 | 1.1.18.3.5 | Financial Team confirms completeness of business scenarios | milestone | 0d | 2008-11-03 12:00 | 2008-11-03 12:00 | 37 | 34.5d |  |  | FIN |  |
| 39 | 1.1.18.3.6 | Logistics Team confirms completeness of business scenarios | milestone | 0d | 2008-11-03 12:00 | 2008-11-03 12:00 | 37 | 34.5d |  | start no earlier than 2008-09-20 08:00 | LOG |  |
| 40 | 1.1.18.3.7 | EHS Team confirms completeness of business scenarios | milestone | 0d | 2008-11-03 12:00 | 2008-11-03 12:00 | 37 | 34.5d |  | start no earlier than 2008-09-20 08:00 | EHS |  |
| 41 | 1.1.18.3.8 | HR-Payroll Team confirms completeness of business scenarios | milestone | 0d | 2008-11-03 12:00 | 2008-11-03 12:00 | 37 | 33.5d | 0d | start no earlier than 2008-09-20 08:00 | HRP |  |
| 42 | 1.1.18.3.9 | QA confirms completeness of business scenarios |  | 1d | 2008-11-03 13:00 | 2008-11-04 12:00 | 41 | 33.5d |  |  | QA | 8h |
| 43 | 1.1.18.4 | **Transport Planning (Final list from R3 on 10/20)** |  | 6d | 2008-10-21 08:00 | 2008-10-28 17:00 |  | 38d |  |  |  | 488h |
| 44 | 1.1.18.4.1 | Produce transport lists (Rel in SF2 not in SF5; Rel in SF5 not in PS1) |  | 1d | 2008-10-21 08:00 | 2008-10-21 17:00 |  | 38d | 0d | start no earlier than 2008-10-21 08:00 | R3 | 8h |
| 45 | 1.1.18.4.2 | Determine which will go to PS1 |  | 5d | 2008-10-22 08:00 | 2008-10-28 17:00 | 44 | 38d |  |  | FIN; LOG; EHS; HRP | 160h |
| 46 | 1.1.18.4.3 | Determine which will go to TST |  | 5d | 2008-10-22 08:00 | 2008-10-28 17:00 | 44 | 38d |  |  | FIN; LOG; EHS; HRP | 160h |
| 47 | 1.1.18.4.4 | Determine which are not needed at this time (will be tested after go live) |  | 5d | 2008-10-22 08:00 | 2008-10-28 17:00 | 44 | 38d |  |  | FIN; LOG; EHS; HRP | 160h |
| 48 | 1.1.18.5 | **User Acceptance Test Planning** |  | 12d | 2008-10-13 08:00 | 2008-10-28 17:00 |  | -0.25d | 0d |  |  | 152h |
| 49 | 1.1.18.5.1 | Send test script catalog to business owners |  | 0.25d | 2008-10-14 08:00 | 2008-10-14 10:00 | 26, 9 | -1.25d | 0d | start no earlier than 2008-10-14 08:00 | FIN; LOG; EHS; HRP | 8h |
| 50 | 1.1.18.5.2 | Business owners select transactions and send back catalogs |  | 10d | 2008-10-13 08:00 | 2008-10-24 17:00 | 49 | -1.25d | 0d | finish no later than 2008-10-24 17:00 | BO | 80h |
| 51 | 1.1.18.5.3 | Business owners define testers and send back list to Team leads |  | 10d | 2008-10-13 08:00 | 2008-10-24 17:00 | 49 | -1.25d | 0d | finish no later than 2008-10-24 17:00 |  |  |
| 52 | 1.1.18.5.4 | Business analysts update test script catalogs |  | 2d | 2008-10-27 08:00 | 2008-10-28 17:00 | 51 | 38d |  |  | FIN; LOG; EHS; HRP | 64h |
| 53 | 1.2 | **System Admin Preparation** |  | 2d | 2008-10-24 08:00 | 2008-10-27 17:00 |  | 39d |  |  |  | 72h |
| 54 | 1.2.1 | Produce Support Package Notes |  | 1d | 2008-10-24 08:00 | 2008-10-24 17:00 |  | 40d |  | start no earlier than 2008-10-24 08:00 | R3 | 8h |
| 55 | 1.2.2 | Review and update action log from previous year |  | 2d | 2008-10-24 08:00 | 2008-10-27 17:00 |  | 39d |  | start no earlier than 2008-10-24 08:00 | FI; LOG; EHS; HRP | 64h |

| ID | WBS | Task | Duration | Start | Finish | Predecessors | Total slack | Free slack | Constraint | Resources | Work |
| --- | --- | --- | --- | --- | --- | --- | --- | --- | --- | --- | --- |
| 56 | 1.3 | **SF3 System Refresh** | 5d | 2008-10-14 08:00 | 2008-10-20 17:00 |  | 44d |  |  |  | 40h |
| 57 | 1.3.1 | Refresh with 9/22/08 PS1 Snapshot | 2d | 2008-10-14 08:00 | 2008-10-15 17:00 |  | 44d | 0d | start no earlier than 2008-10-14 08:00 | R3 | 16h |
| 58 | 1.3.2 | Execute R3 Action Log | 0.5d | 2008-10-16 08:00 | 2008-10-16 12:00 | 57 | 44d | 0d |  | R3 | 4h |
| 59 | 1.3.3 | Scramble sensitive data | 2.5d | 2008-10-16 13:00 | 2008-10-20 17:00 | 58 | 44d |  |  | R3 | 20h |
| 60 | 1.4 | **SFK Update** | 4d | 2008-10-20 08:00 | 2008-10-23 17:00 |  | 10d |  |  |  | 20h |
| 61 | 1.4.1 | Apply SAP kernel update | 0.5d | 2008-10-20 08:00 | 2008-10-20 12:00 | 15 | 10d | 0d | start no earlier than 2008-10-07 08:00 | R3 | 4h |
| 62 | 1.4.2 | Upgrade Oracle db | 0.5d | 2008-10-20 13:00 | 2008-10-20 17:00 | 61 | 10d | 0d |  |  |  |
| 63 | 1.4.3 | Import support packages | 1d | 2008-10-21 08:00 | 2008-10-21 17:00 | 62 | 10d | 0d |  |  |  |
| 64 | 1.4.4 | Identify and resolve import issues | 0.5d | 2008-10-22 08:00 | 2008-10-22 12:00 | 63 | 10d | 0d |  | R3 | 4h |
| 65 | 1.4.5 | Validate security infrastructure (SNC) | 0.5d | 2008-10-22 13:00 | 2008-10-22 17:00 | 64 | 10d | 0d |  | R3 | 4h |
| 66 | 1.4.6 | Validate SAPGui interactions | 0.5d | 2008-10-23 08:00 | 2008-10-23 12:00 | 65 | 10d | 0d |  | R3 | 4h |
| 67 | 1.4.7 | Validate basic SAP functions work | 0.5d | 2008-10-23 13:00 | 2008-10-23 17:00 | 66 | 10d | 0d |  | R3 | 4h |
| 68 | 1.5 | **SF3 Update** | 5.75d | 2008-10-24 08:00 | 2008-10-31 15:00 |  | 10d |  |  |  | 136h |
| 69 | 1.5.1 | Apply SAP kernal update | 0.5d | 2008-10-24 08:00 | 2008-10-24 12:00 | 67 | 10d | 0d |  | R3 | 4h |
| 70 | 1.5.2 | Upgrade Oracle db | 0.5d | 2008-10-24 13:00 | 2008-10-24 17:00 | 69 | 10d | 0d |  | R3 | 4h |
| 71 | 1.5.3 | Import support packages | 1d | 2008-10-27 08:00 | 2008-10-27 17:00 | 70 | 10d | 0d |  | R3 | 8h |
| 72 | 1.5.4 | Apply BSI Tax Factory Update (Rel 8.0 bulletin 110) | 0.25d | 2008-10-28 08:00 | 2008-10-28 10:00 | 71 | 10d | 0d |  | R3 | 2h |
| 73 | 1.5.5 | Execute action log | 0.25d | 2008-10-28 10:00 | 2008-10-28 12:00 | 72 | 10d | 0d |  | DEV; BA | 4h |
| 74 | 1.5.6 | Update action log as necessary | 0.25d | 2008-10-29 08:00 | 2008-10-29 10:00 | 73 | 37.75d |  | start no earlier than 2008-10-29 08:00 | DEV; BA | 4h |
| 75 | 1.5.7 | Produce collision report & post to wiki pages | 0.25d | 2008-10-28 13:00 | 2008-10-28 15:00 | 73 | 10d | 0d |  | R3 | 2h |
| 76 | 1.5.8 | Review collision report | 0.5d | 2008-10-28 15:00 | 2008-10-29 10:00 | 75 | 10d | 0d |  | DEV; BA | 8h |
| 77 | 1.5.9 | Reimplement MIT mods | 2.5d | 2008-10-29 10:00 | 2008-10-31 15:00 | 76 | 35.25d |  |  | DEV | 20h |
| 78 | 1.5.10 | Test RFC connections (IXOS, SAP Fax, SAP Drop box, MIT ID db) | 2.5d | 2008-10-29 10:00 | 2008-10-31 15:00 | 76 | 10d | 0d |  | R3 | 20h |
| 79 | 1.5.11 | **Test SAPWeb Applications** | 2.5d | 2008-10-29 10:00 | 2008-10-31 15:00 |  | 35.25d |  |  |  | 40h |
| 80 | 1.5.11.1 | Test ITS app's (no gateway pages) | 2.5d | 2008-10-29 10:00 | 2008-10-31 15:00 | 76 | 35.25d |  |  | IDD | 20h |
| 81 | 1.5.11.2 | Test OAS app's (no gateway pages) | 2.5d | 2008-10-29 10:00 | 2008-10-31 15:00 | 76 | 35.25d |  |  | IDD | 20h |
| 82 | 1.5.12 | Test BSI Tax Factory Updates | 2.5d | 2008-10-29 10:00 | 2008-10-31 15:00 | 76 | 35.25d |  |  | FQ | 20h |

| ID | WBS | Task | Type | Duration | Start | Finish | Predecessors | Total slack | Free slack | Constraint | Resources | Work |
| --- | --- | --- | --- | --- | --- | --- | --- | --- | --- | --- | --- | --- |
| 83 | 1.6 | **SF2 System Preparation** |  | 3.25d | 2008-10-31 15:00 | 2008-11-05 17:00 |  | 10d |  |  |  | 30h |
| 84 | 1.6.1 | Apply SAP kernel update |  | 0.5d | 2008-10-31 15:00 | 2008-11-03 10:00 | 78 | 10d | 0d |  | R3 | 4h |
| 85 | 1.6.2 | Upgrade Oracle db |  | 0.5d | 2008-11-03 10:00 | 2008-11-03 15:00 | 84 | 10d | 0d |  | R3 | 4h |
| 86 | 1.6.3 | Import support packages |  | 1d | 2008-11-03 15:00 | 2008-11-04 15:00 | 85 | 10d | 0d | start no earlier than 2008-11-03 08:00 | R3 | 8h |
| 87 | 1.6.4 | Apply BSI Tax Factory Update |  | 0.25d | 2008-11-04 15:00 | 2008-11-04 17:00 | 86 | 10d | 0d |  | R3 | 2h |
| 88 | 1.6.5 | Execute action log (add updates if necessary) |  | 0.5d | 2008-11-05 08:00 | 2008-11-05 12:00 | 87 | 10d | 0d |  | BA; DEV | 8h |
| 89 | 1.6.6 | Import transports from SF3 |  | 0.5d | 2008-11-05 13:00 | 2008-11-05 17:00 | 88 | 10d | 0d |  | R3 | 4h |
| 90 | 1.7 | **Unit Test Execution in SF2** |  | 3d | 2008-11-06 08:00 | 2008-11-10 17:00 | 89 | 10d |  |  |  | 96h |
| 91 | 1.7.1 | Financial Unit Tests, Issue identification and retest |  | 3d | 2008-11-06 08:00 | 2008-11-10 17:00 | 89 | 29d |  |  | FIN | 24h |
| 92 | 1.7.2 | Logistics Unit Tests, Issue identification and retest |  | 3d | 2008-11-06 08:00 | 2008-11-10 17:00 | 89 | 29d |  |  | LOG | 24h |
| 93 | 1.7.3 | EHS Unit Tests, Issue identification and retest |  | 3d | 2008-11-06 08:00 | 2008-11-10 17:00 | 89 | 29d |  |  | EHS | 24h |
| 94 | 1.7.4 | HR-Payroll Unit Tests, Issue identification and retest |  | 3d | 2008-11-06 08:00 | 2008-11-10 17:00 | 89 | 10d | 0d |  | HRP | 24h |
| 95 | 1.7.5 | All functional teams ok environment and move to SIT | milestone | 0d | 2008-11-10 17:00 | 2008-11-10 17:00 | 94 | 10d | 0d |  | BA; DEV |  |
| 96 | 1.8 | **SF6 System Preparation** |  | 8.75d | 2008-10-27 08:00 | 2008-11-06 15:00 |  | 13.25d |  |  |  | 50h |
| 97 | 1.8.1 | Refresh SF6 w/ 10/20 snapshot (no data scrambling) |  | 3d | 2008-10-27 08:00 | 2008-10-29 17:00 |  | 13.25d | 0d | start no earlier than 2008-10-27 08:00 |  |  |
| 98 | 1.8.2 | Import post snapshot production transports (delta from 10/20 to 10/30) |  | 0.5d | 2008-10-30 08:00 | 2008-10-30 12:00 | 97 | 13.25d | 0d |  | R3 | 4h |
| 99 | 1.8.3 | Apply kernel update |  | 0.5d | 2008-10-30 13:00 | 2008-10-30 17:00 | 98 | 13.25d | 0d |  | R3 | 4h |
| 100 | 1.8.4 | Upgrade Oracle db |  | 0.5d | 2008-10-31 08:00 | 2008-10-31 12:00 | 99 | 13.25d | 0d |  | R3 | 4h |
| 101 | 1.8.5 | Import support packages |  | 1d | 2008-10-31 13:00 | 2008-11-03 12:00 | 100 | 13.25d | 0d |  | R3 | 8h |
| 102 | 1.8.6 | Apply BSI Tax Factory Update |  | 0.25d | 2008-11-03 13:00 | 2008-11-03 15:00 | 101 | 13.25d | 0d |  | R3 | 2h |
| 103 | 1.8.7 | Import SF3 transports & post-update DEV transports (to be tested during SI & UAT) |  | 1d | 2008-11-03 15:00 | 2008-11-04 15:00 | 102 | 13.25d | 0d |  | DEV | 8h |
| 104 | 1.8.8 | Execute trial balance and compare with TB from 10/20 |  | 0.5d | 2008-11-04 15:00 | 2008-11-05 10:00 | 101, 103 | 13.25d | 0d |  | BUS | 4h |
| 105 | 1.8.9 | Execute action log |  | 0.5d | 2008-11-05 10:00 | 2008-11-05 15:00 | 104 | 13.25d | 0d |  | DEV; BA | 8h |
| 106 | 1.8.10 | Execute DWH extracts and comparison |  | 1d | 2008-11-05 15:00 | 2008-11-06 15:00 | 105 | 31.25d |  |  | DWH | 8h |

| ID | WBS | Task | Type | Duration | Start | Finish | Predecessors | Total slack | Free slack | Constraint | Resources | Work |
| --- | --- | --- | --- | --- | --- | --- | --- | --- | --- | --- | --- | --- |
| 107 | 1.9 | **Execute System Integration Tests** |  | 6d | 2008-11-12 08:00 | 2008-11-19 17:00 |  | 10d |  |  |  | 384h |
| 108 | 1.9.1 | HR-Payroll SIT, Issue identification and retest |  | 6d | 2008-11-12 08:00 | 2008-11-19 17:00 | 105, 95 | 23d |  |  | DEV; BA | 96h |
| 109 | 1.9.2 | Logistics SIT, Issue identification and retest |  | 6d | 2008-11-12 08:00 | 2008-11-19 17:00 | 105, 95 | 23d |  |  | DEV; BA | 96h |
| 110 | 1.9.3 | EHS SIT, Issue identification and retest |  | 6d | 2008-11-12 08:00 | 2008-11-19 17:00 | 105, 95 | 23d |  |  | DEV; BA | 96h |
| 111 | 1.9.4 | Financial SIT, Issue identification and retest |  | 6d | 2008-11-12 08:00 | 2008-11-19 17:00 | 105, 95 | 10d | 0d |  | DEV; BA | 96h |
| 112 | 1.10 | **Execute User Acceptance Test (UAT)** |  | 15d | 2008-11-20 08:00 | 2008-12-12 17:00 |  | 8d |  |  |  | 112h |
| 113 | 1.10.1 | Execute UAT |  | 8d | 2008-11-20 08:00 | 2008-12-03 17:00 | 111 | 10d | 0d |  | BUS | 64h |
| 114 | 1.10.2 | Financial Close |  | 2d | 2008-12-04 08:00 | 2008-12-05 17:00 | 113 | 10d | 0d |  | BUS | 16h |
| 115 | 1.10.3 | Issue retesting |  | 2d | 2008-12-08 08:00 | 2008-12-09 17:00 | 114 | 10d | 0d |  | ALL | 16h |
| 116 | 1.10.4 | Execute another financial close? (done no later than 12/12) |  | 1d | 2008-12-10 08:00 | 2008-12-10 17:00 | 115 | 10d |  |  | BUS | 8h |
| 117 | 1.10.5 | UAT sign off (preferred 12/11, no later than 12/12) |  | 1d | 2008-12-12 08:00 | 2008-12-12 17:00 |  | 7.75d | 0d | start no earlier than 2008-12-12 08:00 | ALL | 8h |
| 118 | 1.11 | **Cutover weekend & Controlled Start** |  | 0.25d | 2008-12-13 08:00 | 2008-12-13 10:00 | 117 | 7.75d |  |  | ALL | 2h |
| 119 | 1.11.1 | System message put out on SAP |  | 0.25d | 2008-12-13 08:00 | 2008-12-13 10:00 |  | 7.75d |  | start no earlier than 2008-12-08 08:00 |  |  |
| 120 | 1.11.2 | System message put out on SAPWeb pages |  | 0.25d | 2008-12-13 08:00 | 2008-12-13 10:00 |  | 7.75d |  | start no earlier than 2008-12-08 08:00 |  |  |
| 121 | 1.12 | Drop Dead Date for support packs in production | milestone | 0d | 2008-12-22 08:00 | 2008-12-22 08:00 |  | 1d |  | start no earlier than 2008-12-22 08:00 |  |  |
| 122 | 1.13 | First Calendar 2009 Payroll | milestone | 0d | 2008-12-23 08:00 | 2008-12-23 08:00 |  | 0d |  | start no earlier than 2008-12-23 08:00 |  |  |
