# High Level Plan for SAPBiz 10-22-08 v4

Schedule from MS Project, 2008-09-22 to 2008-12-23.
MIT

## Calendars

- Standard: Mon-Fri 08:00-12:00, 13:00-17:00; Sat-Sun off. Exceptions (off unless hours are given): 2008-11-11, 2008-11-27 to 2008-11-30, 2008-12-06, 2008-12-13 to 2008-12-14 08:00-12:00, 13:00-17:00.

## Resources

| Resource |
| --- |
| ABAP |
| BO |
| CAO |
| BASIS |
| BA |
| DEV |
| DWH |
| HR-P |
| ALL |
| 20 |
| BUS |
| 8 |
| 7 |
| REP |
| R3 |

## Schedule

| ID | WBS | Task | Type | Duration | Start | Finish | Predecessors | Total slack | Free slack | Constraint | Resources | Work |
| --- | --- | --- | --- | --- | --- | --- | --- | --- | --- | --- | --- | --- |
| 1 | 1 | **2008 Support Pack Implementation Project** |  | 65d | 2008-09-22 | 2008-12-23 |  | 0d |  |  |  | 1228h |
| 2 | 1.1 | **Project Prep** |  | 30d | 2008-09-22 | 2008-10-31 |  | 35d |  |  |  | 404h |
| 3 | 1.1.1 | PS1 Snapshot at end of day | milestone | 0d | 2008-09-22 | 2008-09-22 |  | 66d |  | start no earlier than 2008-09-22 |  |  |
| 4 | 1.1.2 | Transaction list available | milestone | 0d | 2008-09-26 | 2008-09-26 |  | 36d | 1d | start no earlier than 2008-09-26 | R3 |  |
| 5 | 1.1.3 | Identify test scenarios / transactions |  | 5d | 2008-09-29 | 2008-10-03 | 4 | 35d | 0d | start no earlier than 2008-09-29 | BUS; BA | 80h |
| 6 | 1.1.4 | Review and update test scripts |  | 20d | 2008-10-06 | 2008-10-31 | 5 | 35d |  |  | BUS; BA | 320h |
| 7 | 1.1.5 | SF3 Unavailable at end of day | milestone | 0d | 2008-10-10 | 2008-10-10 |  | 52d | 0d | start no earlier than 2008-10-10 |  |  |
| 8 | 1.1.6 | PS1 snapshot at end of day | milestone | 0d | 2008-10-20 | 2008-10-20 |  | 44.5d | 0d | start no earlier than 2008-10-20 | R3 |  |
| 9 | 1.1.7 | Execute Trial balance for snapshot |  | 0.5d | 2008-10-20 | 2008-10-20 | 8 | 44.5d |  | start no earlier than 2008-10-20 | BUS | 4h |
| 10 | 1.1.8 | Save data warehouse extracts | milestone | 0d | 2008-10-10 | 2008-10-10 | 7 | 51d |  |  | DWH |  |
| 11 | 1.1.9 | Support packs available from SAP | milestone | 0d | 2008-10-20 | 2008-10-20 |  | 46d |  | start no earlier than 2008-10-20 |  |  |
| 12 | 1.1.10 | PS1 Import 1 | milestone | 0d | 2008-10-23 | 2008-10-23 |  | 43d |  | start no earlier than 2008-10-23 |  |  |
| 13 | 1.2 | **SF3 System Refresh** |  | 5d | 2008-10-14 | 2008-10-20 |  | 4.5d |  |  |  | 44h |
| 14 | 1.2.1 | Refresh with 9/22/08 PS1 Snapshot |  | 2d | 2008-10-14 | 2008-10-15 |  | 44d | 0d | start no earlier than 2008-10-14 | R3 | 16h |
| 15 | 1.2.2 | R3 Action Log |  | 0.5d | 2008-10-16 | 2008-10-16 | 14 | 44d | 0d |  | R3 | 4h |
| 16 | 1.2.3 | Scramble sensitive data |  | 2.5d | 2008-10-16 | 2008-10-20 | 15 | 44d |  |  | R3 | 20h |
| 17 | 1.2.4 | PS1 Snapshot at end of day | milestone | 0d | 2008-10-20 | 2008-10-20 |  | 44.5d | 0d | start no earlier than 2008-10-20 |  |  |
| 18 | 1.2.5 | Execute Trial Balance for later comparison |  | 0.5d | 2008-10-20 | 2008-10-20 | 17 | 44.5d |  |  | R3 | 4h |
| 19 | 1.2.6 | Support Packs available from SAP | milestone | 0d | 2008-10-20 | 2008-10-20 |  | 0.5d | 0d | start no earlier than 2008-10-20 |  |  |
| 20 | 1.3 | **SFK Update** |  | 4d | 2008-10-21 | 2008-10-24 |  | 0.5d |  |  |  | 32h |
| 21 | 1.3.1 | Import Updates |  | 1d | 2008-10-21 | 2008-10-21 | 19FS+1d | 0.5d | 0d | start no earlier than 2008-10-07 | R3 | 8h |
| 22 | 1.3.2 | Identify and resolve import issues |  | 1d | 2008-10-22 | 2008-10-22 | 21 | 0.5d | 0d |  | R3 | 8h |
| 23 | 1.3.3 | Validate security infrastructure (SNC) |  | 1d | 2008-10-23 | 2008-10-23 | 22 | 0.5d | 0d |  | R3 | 8h |
| 24 | 1.3.4 | Validate SAPGui interactions |  | 0.5d | 2008-10-24 | 2008-10-24 | 23 | 0.5d | 0d |  | R3 | 4h |
| 25 | 1.3.5 | Validate basic SAP functions work |  | 0.5d | 2008-10-24 | 2008-10-24 | 24 | 0.5d | 0d |  | R3 | 4h |
| 26 | 1.4 | PS1 Import - regular import cycle | milestone | 0d | 2008-10-23 | 2008-10-23 |  | 2d | 0d | start no earlier than 2008-10-23 |  |  |

| ID | WBS | Task | Type | Duration | Start | Finish | Predecessors | Total slack | Free slack | Constraint | Resources | Work |
| --- | --- | --- | --- | --- | --- | --- | --- | --- | --- | --- | --- | --- |
| 27 | 1.5 | **SF3 Update** |  | 5d | 2008-10-27 | 2008-10-31 |  | 0.5d |  |  |  | 68h |
| 28 | 1.5.1 | Import Updates |  | 2d | 2008-10-27 | 2008-10-28 | 19, 25 | 0.5d | 0d |  | R3 | 16h |
| 29 | 1.5.2 | Execute action log |  | 0.5d | 2008-10-29 | 2008-10-29 | 28 | 37.5d |  |  | DEV; BA | 8h |
| 30 | 1.5.3 | Update action log as necessary |  | 0.5d | 2008-10-29 | 2008-10-29 |  | 37.5d |  | start no earlier than 2008-10-29 | DEV; BA | 8h |
| 31 | 1.5.4 | Produce collision report |  | 0.5d | 2008-10-29 | 2008-10-29 | 28 | 0.5d | 0d |  | R3 | 4h |
| 32 | 1.5.5 | Review collision report |  | 1d | 2008-10-29 | 2008-10-30 | 31 | 0.5d | 0d |  | DEV; BA | 16h |
| 33 | 1.5.6 | Reimplement MIT mods |  | 1d | 2008-10-30 | 2008-10-31 | 32 | 0.5d | 0d |  | DEV | 8h |
| 34 | 1.5.7 | Confirm configuration steps work |  | 0.5d | 2008-10-31 | 2008-10-31 | 33 | 35d |  |  | DEV; BA | 8h |
| 35 | 1.6 | Production Imports (last regular import cycle) | milestone | 0d | 2008-10-30 | 2008-10-30 |  | 37d | 1d | start no earlier than 2008-10-30 |  |  |
| 36 | 1.7 | Development slowdown starts | milestone | 0d | 2008-10-31 | 2008-10-31 | 35 | 36d |  | start no earlier than 2008-10-31 |  |  |
| 37 | 1.8 | **Unit Test Preparation and Execution** |  | 6d | 2008-11-03 | 2008-11-10 |  | 0d |  |  |  | 76h |
| 38 | 1.8.1 | Apply support packs to SF2 |  | 2d | 2008-11-03 | 2008-11-04 | 33 | 0d |  | start no earlier than 2008-11-03 | R3 | 16h |
| 39 | 1.8.2 | Update and Execute action log |  | 0.5d | 2008-11-05 | 2008-11-05 | 38 | 0d |  |  | BA; DEV | 8h |
| 40 | 1.8.3 | Import transports from SF3 |  | 0.5d | 2008-11-05 | 2008-11-05 | 39 | 0d |  |  | R3 | 4h |
| 41 | 1.8.4 | Unit test, resolution and retest in SF2 |  | 3d | 2008-11-06 | 2008-11-10 | 40 | 0d |  |  | BA; DEV | 48h |
| 42 | 1.9 | **System Test / User Acceptance Test Environment Preparations** |  | 10d | 2008-10-27 | 2008-11-07 |  | 2d |  |  |  | 84h |
| 43 | 1.9.1 | Refresh TST with 10/20 snapshot, NO SCRAMBLING DATA |  | 3d | 2008-10-27 | 2008-10-29 |  | 2d | 0d | start no earlier than 2008-10-27 | R3 | 24h |
| 44 | 1.9.2 | Import post snapshot production transports (delta from 10/20 to 10/30) |  | 2d | 2008-10-30 | 2008-10-31 | 43 | 2d | 0d |  | R3 | 16h |
| 45 | 1.9.3 | Import updates |  | 2d | 2008-11-03 | 2008-11-04 | 44 | 2d | 0d |  | R3 | 16h |
| 46 | 1.9.4 | Import SF3 transports & post-update DEV transports (to be tested during SI & UAT) |  | 1d | 2008-11-05 | 2008-11-05 | 45 | 2d | 0d |  | DEV | 8h |
| 47 | 1.9.5 | Execute trial balance and compare with TB from 10/20 |  | 0.5d | 2008-11-06 | 2008-11-06 | 45, 46 | 2d | 0d |  | BUS | 4h |
| 48 | 1.9.6 | Execute action log |  | 0.5d | 2008-11-06 | 2008-11-06 | 47 | 2d | 0d |  | DEV; BA | 8h |
| 49 | 1.9.7 | Execute DWH extracts and comparison |  | 1d | 2008-11-07 | 2008-11-07 | 48 | 30d |  |  | DWH | 8h |
| 50 | 1.10 | **Execute System Integration Tests** |  | 6d | 2008-11-12 | 2008-11-19 |  | 0d |  |  |  | 384h |
| 51 | 1.10.1 | HR-Payroll |  | 6d | 2008-11-12 | 2008-11-19 | 48, 41 | 23d |  |  | DEV; BA | 96h |
| 52 | 1.10.2 | Logistics |  | 6d | 2008-11-12 | 2008-11-19 | 48, 41 | 23d |  |  | DEV; BA | 96h |
| 53 | 1.10.3 | EHS |  | 6d | 2008-11-12 | 2008-11-19 | 48, 41 | 23d |  |  | DEV; BA | 96h |
| 54 | 1.10.4 | Financial |  | 6d | 2008-11-12 | 2008-11-19 | 48, 41 | 0d |  |  | DEV; BA | 96h |

| ID | WBS | Task | Type | Duration | Start | Finish | Predecessors | Total slack | Constraint | Resources | Work |
| --- | --- | --- | --- | --- | --- | --- | --- | --- | --- | --- | --- |
| 55 | 1.11 | **Execute User Acceptance Test (UAT)** |  | 15d | 2008-11-20 | 2008-12-12 |  | 0d |  |  | 120h |
| 56 | 1.11.1 | Execute UAT |  | 9d | 2008-11-20 | 2008-12-04 | 54 | 0d |  | BUS | 72h |
| 57 | 1.11.2 | Financial Close |  | 2d | 2008-12-05 | 2008-12-08 | 56 | 0d |  | BUS | 16h |
| 58 | 1.11.3 | Issue retesting |  | 2d | 2008-12-09 | 2008-12-10 | 57 | 0d |  | ALL | 16h |
| 59 | 1.11.4 | Execute another financial close? |  | 1d | 2008-12-11 | 2008-12-11 | 58 | 0d |  | BUS | 8h |
| 60 | 1.11.5 | UAT sign off |  | 1d | 2008-12-12 | 2008-12-12 | 59 | 0d |  | ALL | 8h |
| 61 | 1.12 | Cutover weekend & Controlled Start |  | 2d | 2008-12-13 | 2008-12-14 | 60 | 0d | start no later than 2008-12-13 | ALL | 16h |
| 62 | 1.13 | Drop Dead Date for support packs in production | milestone | 0d | 2008-12-22 | 2008-12-22 |  | 1d | start no earlier than 2008-12-22 |  |  |
| 63 | 1.14 | First Calendar 2009 Payroll | milestone | 0d | 2008-12-23 | 2008-12-23 |  | 0d | start no earlier than 2008-12-23 |  |  |
