# High Level Plan for SAPBiz 10-8-08 v4

Schedule from MS Project, 2008-09-22 to 2008-12-23.
MIT

## Calendars

- Standard: Mon-Fri 08:00-12:00, 13:00-17:00; Sat-Sun off. Exceptions (off unless hours are given): 2008-11-11, 2008-11-27 to 2008-11-30, 2008-12-06, 2008-12-13 to 2008-12-14 08:00-12:00, 13:00-17:00.

## Resources

| Resource |
| --- |
| ABAP |
| BO |
| CAO |
| BASIS |
| BA |
| DEV |
| DWH |
| HR-P |
| ALL |
| 20 |
| BUS |
| 8 |
| 7 |
| REP |
| R3 |

## Schedule

| ID | WBS | Task | Type | Duration | Start | Finish | Predecessors | Total slack | Free slack | Constraint | Resources | Work |
| --- | --- | --- | --- | --- | --- | --- | --- | --- | --- | --- | --- | --- |
| 1 | 1 | **2008 Support Pack Implementation Project** |  | 65d | 2008-09-22 | 2008-12-23 |  | 0d |  |  |  | 1252h |
| 2 | 1.1 | **Project Prep** |  | 33d | 2008-09-22 | 2008-11-06 |  | 32d |  |  |  | 404h |
| 3 | 1.1.1 | PS1 Snapshot at end of day | milestone | 0d | 2008-09-22 | 2008-09-22 |  | 66d |  | start no earlier than 2008-09-22 |  |  |
| 4 | 1.1.2 | Transaction list available | milestone | 0d | 2008-09-26 | 2008-09-26 |  | 36d | 1d | start no earlier than 2008-09-26 | R3 |  |
| 5 | 1.1.3 | Identify test scenarios / transactions |  | 5d | 2008-09-29 | 2008-10-03 | 4 | 35d | 0d | start no earlier than 2008-09-29 | BUS; BA | 80h |
| 6 | 1.1.4 | Review and update test scripts |  | 20d | 2008-10-06 | 2008-10-31 | 5 | 35d |  |  | BUS; BA | 320h |
| 7 | 1.1.5 | SF3 Unavailable at end of day | milestone | 0d | 2008-10-10 | 2008-10-10 |  | 52d | 0d | start no earlier than 2008-10-10 |  |  |
| 8 | 1.1.6 | PS1 snapshot at end of day | milestone | 0d | 2008-10-20 | 2008-10-20 |  | 44.5d | 0d | start no earlier than 2008-10-20 | R3 |  |
| 9 | 1.1.7 | Execute Trial balance for snapshot |  | 0.5d | 2008-10-20 | 2008-10-20 | 8 | 44.5d |  | start no earlier than 2008-10-20 | BUS | 4h |
| 10 | 1.1.8 | Save data warehouse extracts | milestone | 0d | 2008-10-10 | 2008-10-10 | 7 | 51d |  |  | DWH |  |
| 11 | 1.1.9 | Support packs available from SAP | milestone | 0d | 2008-10-20 | 2008-10-20 |  | 46d |  | start no earlier than 2008-10-20 |  |  |
| 12 | 1.1.10 | PS1 Import 1 | milestone | 0d | 2008-10-23 | 2008-10-23 |  | 43d |  | start no earlier than 2008-10-23 |  |  |
| 13 | 1.1.11 | PS1 Import 2 | milestone | 0d | 2008-10-30 | 2008-10-30 |  | 38d |  | start no earlier than 2008-10-30 |  |  |
| 14 | 1.1.12 | PS1 Import 3 | milestone | 0d | 2008-11-06 | 2008-11-06 |  | 33d |  | start no earlier than 2008-11-06 |  |  |
| 15 | 1.2 | **SF3 System Refresh** |  | 5d | 2008-10-14 | 2008-10-20 |  | 4d |  |  |  | 44h |
| 16 | 1.2.1 | Refresh with 9/22/08 PS1 Snapshot |  | 2d | 2008-10-14 | 2008-10-15 |  | 44d | 0d | start no earlier than 2008-10-14 | R3 | 16h |
| 17 | 1.2.2 | R3 Action Log |  | 0.5d | 2008-10-16 | 2008-10-16 | 16 | 44d | 0d |  | R3 | 4h |
| 18 | 1.2.3 | Scramble sensitive data |  | 2.5d | 2008-10-16 | 2008-10-20 | 17 | 44d |  |  | R3 | 20h |
| 19 | 1.2.4 | PS1 Snapshot at end of day | milestone | 0d | 2008-10-20 | 2008-10-20 |  | 45.5d | 0d | start no earlier than 2008-10-20 |  |  |
| 20 | 1.2.5 | Execute Trial Balance for later comparison |  | 0.5d | 2008-10-20 | 2008-10-20 | 19 | 44.5d |  |  | R3 | 4h |
| 21 | 1.2.6 | Support Packs available from SAP | milestone | 0d | 2008-10-20 | 2008-10-20 |  | 0d |  | start no earlier than 2008-10-20 |  |  |
| 22 | 1.3 | **SFK Update** |  | 4d | 2008-10-21 | 2008-10-24 |  | 0d |  |  |  | 32h |
| 23 | 1.3.1 | Import Updates |  | 1d | 2008-10-21 | 2008-10-21 | 21FS+1d | 0d |  | start no earlier than 2008-10-07 | R3 | 8h |
| 24 | 1.3.2 | Identify and resolve import issues |  | 1d | 2008-10-22 | 2008-10-22 | 23 | 0d |  |  | R3 | 8h |
| 25 | 1.3.3 | Validate security infrastructure (SNC) |  | 1d | 2008-10-23 | 2008-10-23 | 24 | 0d |  |  | R3 | 8h |
| 26 | 1.3.4 | Validate SAPGui interactions |  | 0.5d | 2008-10-24 | 2008-10-24 | 25 | 0d |  |  | R3 | 4h |
| 27 | 1.3.5 | Validate basic SAP functions work |  | 0.5d | 2008-10-24 | 2008-10-24 | 26 | 0d |  |  | R3 | 4h |

| ID | WBS | Task | Type | Duration | Start | Finish | Predecessors | Total slack | Free slack | Constraint | Resources | Work |
| --- | --- | --- | --- | --- | --- | --- | --- | --- | --- | --- | --- | --- |
| 28 | 1.4 | **SF3 Update** |  | 5d | 2008-10-27 | 2008-10-31 |  | 0d |  |  |  | 68h |
| 29 | 1.4.1 | Import Updates |  | 2d | 2008-10-27 | 2008-10-28 | 21, 27 | 0d |  |  | R3 | 16h |
| 30 | 1.4.2 | Execute action log |  | 0.5d | 2008-10-29 | 2008-10-29 | 29 | 37.5d |  |  | DEV; BA | 8h |
| 31 | 1.4.3 | Update action log as necessary |  | 0.5d | 2008-10-29 | 2008-10-29 |  | 37.5d |  | start no earlier than 2008-10-29 | DEV; BA | 8h |
| 32 | 1.4.4 | Produce collision report |  | 0.5d | 2008-10-29 | 2008-10-29 | 29 | 0d |  |  | R3 | 4h |
| 33 | 1.4.5 | Review collision report |  | 1d | 2008-10-29 | 2008-10-30 | 32 | 0d |  |  | DEV; BA | 16h |
| 34 | 1.4.6 | Reimplement MIT mods |  | 1d | 2008-10-30 | 2008-10-31 | 33 | 0d |  |  | DEV | 8h |
| 35 | 1.4.7 | Confirm configuration steps work |  | 0.5d | 2008-10-31 | 2008-10-31 | 34 | 0d |  |  | DEV; BA | 8h |
| 36 | 1.5 | **Unit Test Preparation and Execution** |  | 6d | 2008-11-03 | 2008-11-10 |  | 0d |  |  |  | 76h |
| 37 | 1.5.1 | Apply support packs to SF2 |  | 2d | 2008-11-03 | 2008-11-04 | 35 | 0d |  |  | R3 | 16h |
| 38 | 1.5.2 | Update and Execute action log |  | 0.5d | 2008-11-05 | 2008-11-05 | 37 | 0d |  |  | BA; DEV | 8h |
| 39 | 1.5.3 | Import transports from SF3 |  | 0.5d | 2008-11-05 | 2008-11-05 | 38 | 0d |  |  | R3 | 4h |
| 40 | 1.5.4 | Unit test, resolution and retest in SF2 |  | 3d | 2008-11-06 | 2008-11-10 | 39 | 0d |  |  | BA; DEV | 48h |
| 41 | 1.6 | **System Test / User Acceptance Test Environment Preparations** |  | 10d | 2008-10-27 | 2008-11-07 |  | 2d |  |  |  | 84h |
| 42 | 1.6.1 | Refresh TST with 10/20 snapshot, NO SCRAMBLING DATA |  | 3d | 2008-10-27 | 2008-10-29 |  | 32d | 0d | start no earlier than 2008-10-27 | R3 | 24h |
| 43 | 1.6.2 | Import post snapshot production transports (delta from 10/20 to 10/30) |  | 2d | 2008-10-30 | 2008-10-31 | 42 | 2d | 0d |  | R3 | 16h |
| 44 | 1.6.3 | Import updates |  | 2d | 2008-11-03 | 2008-11-04 | 43 | 2d | 0d |  | R3 | 16h |
| 45 | 1.6.4 | Import SF3 transports & post-update DEV transports (to be tested during SI & UAT) |  | 1d | 2008-11-05 | 2008-11-05 | 44 | 2d | 0d |  | DEV | 8h |
| 46 | 1.6.5 | Execute trial balance and compare with TB from 10/20 |  | 0.5d | 2008-11-06 | 2008-11-06 | 44, 45 | 2d | 0d |  | BUS | 4h |
| 47 | 1.6.6 | Execute action log |  | 0.5d | 2008-11-06 | 2008-11-06 | 46 | 2d | 0d |  | DEV; BA | 8h |
| 48 | 1.6.7 | Execute DWH extracts and comparison |  | 1d | 2008-11-07 | 2008-11-07 | 47 | 30d | 0d |  | DWH | 8h |
| 49 | 1.6.8 | Development slowdown starts | milestone | 0d | 2008-11-07 | 2008-11-07 | 48 | 30d |  |  |  |  |
| 50 | 1.7 | **Execute System Integration Tests** |  | 6d | 2008-11-12 | 2008-11-19 |  | 0d |  |  |  | 384h |
| 51 | 1.7.1 | HR-Payroll |  | 6d | 2008-11-12 | 2008-11-19 | 47, 40 | 23d |  |  | DEV; BA | 96h |
| 52 | 1.7.2 | Logistics |  | 6d | 2008-11-12 | 2008-11-19 | 47, 40 | 23d |  |  | DEV; BA | 96h |
| 53 | 1.7.3 | EHS |  | 6d | 2008-11-12 | 2008-11-19 | 47, 40 | 23d |  |  | DEV; BA | 96h |
| 54 | 1.7.4 | Financial |  | 6d | 2008-11-12 | 2008-11-19 | 47, 40 | 0d |  |  | DEV; BA | 96h |

| ID | WBS | Task | Type | Duration | Start | Finish | Predecessors | Total slack | Constraint | Resources | Work |
| --- | --- | --- | --- | --- | --- | --- | --- | --- | --- | --- | --- |
| 55 | 1.8 | **Execute User Acceptance Test (UAT)** |  | 15d | 2008-11-20 | 2008-12-12 |  | 0d |  |  | 144h |
| 56 | 1.8.1 | Payroll comparison (tasks and duration to be validated) |  | 3d | 2008-11-20 | 2008-11-24 | 54 | 0d |  | BA; BUS | 48h |
| 57 | 1.8.2 | Execute UAT |  | 7d | 2008-11-25 | 2008-12-05 | 56 | 0d |  | BUS | 56h |
| 58 | 1.8.3 | Financial Close |  | 1d | 2008-12-08 | 2008-12-08 | 57 | 0d |  | BUS | 8h |
| 59 | 1.8.4 | Issue retesting |  | 2d | 2008-12-09 | 2008-12-10 | 58 | 0d |  | ALL | 16h |
| 60 | 1.8.5 | Execute another financial close? |  | 1d | 2008-12-11 | 2008-12-11 | 59 | 0d |  | BUS | 8h |
| 61 | 1.8.6 | UAT sign off |  | 1d | 2008-12-12 | 2008-12-12 | 60 | 0d |  | ALL | 8h |
| 62 | 1.9 | Cutover weekend & Controlled Start |  | 2d | 2008-12-13 | 2008-12-14 | 61 | 0d | start no later than 2008-12-13 | ALL | 16h |
| 63 | 1.10 | Drop Dead Date for support packs in production | milestone | 0d | 2008-12-22 | 2008-12-22 |  | 1d | start no earlier than 2008-12-22 |  |  |
| 64 | 1.11 | First Calendar 2009 Payroll | milestone | 0d | 2008-12-23 | 2008-12-23 |  | 0d | start no earlier than 2008-12-23 |  |  |
